# Tracking Gantt

Schedule from MS Project, 2003-08-04 to 2003-10-17, costs in $, A marks actual dates.
General Physics Corporation

## Calendars

- Standard: Mon-Fri 08:00-12:00, 13:00-17:00; Sat-Sun off.

## Resources

| Resource |
| --- |
| Technician |

## Schedule

| ID | Task | Type | Duration | Start | Finish | Predecessors | Complete | Baseline start | Baseline finish | Baseline duration | Total slack | Resources | Work | Actual work | Cost | Actual cost |
| --- | --- | --- | --- | --- | --- | --- | --- | --- | --- | --- | --- | --- | --- | --- | --- | --- |
| 1 | Project Award | milestone | 0d | 2003-08-04 A | 2003-08-04 A |  | 100% | 2003-08-04 | 2003-08-04 | 0d |  |  |  |  |  |  |
| 2 | Project Kickoff Activities |  | 2w | 2003-08-04 A | 2003-08-15 A | 1 | 100% | 2003-08-04 | 2003-08-15 | 2w |  | Technician [300%] | 240h | 240h | 16,000 | 16,000 |
| 3 | Parts Analysis |  | 2w | 2003-08-25 A | 2003-09-05 A | 2 | 100% | 2003-08-25 | 2003-08-29 | 1w |  | Technician [400%] | 320h | 320h | 20,000 | 20,000 |
| 4 | Preliminary Design |  | 3w | 2003-08-18 A | 2003-09-05 A | 2 | 100% | 2003-08-18 | 2003-09-05 | 3w |  | Technician [300%] | 360h | 360h | 24,000 | 24,000 |
| 5 | Preliminary Test Plan |  | 1w | 2003-08-18 A | 2003-08-22 A | 2 | 100% | 2003-08-18 | 2003-08-22 | 1w |  | Technician [300%] | 120h | 120h | 6,000 | 6,000 |
| 6 | Catalog Development |  | 4w | 2003-09-08 | 2003-10-03 | 3 |  | 2003-09-01 | 2003-09-26 | 4w | 5d | Technician [300%] | 480h |  | 20,000 |  |
| 7 | Parts Received |  | 3w | 2003-09-08 | 2003-09-26 | 3 |  | 2003-09-01 | 2003-09-19 | 3w | 0d | Technician | 120h |  | 9,000 |  |
| 8 | Final Design |  | 2w | 2003-09-08 | 2003-09-19 | 4 |  | 2003-09-08 | 2003-09-19 | 2w | 5d | Technician [200%] | 160h |  | 4,000 |  |
| 9 | Final Test Plan |  | 1w | 2003-09-22 | 2003-09-26 | 5, 4 |  | 2003-09-22 | 2003-09-26 | 1w | 5d | Technician [200%] | 80h |  | 8,000 |  |
| 10 | Assembly |  | 2w | 2003-09-29 | 2003-10-10 | 7, 8 |  | 2003-09-22 | 2003-10-03 | 2w | 0d | Technician [200%] | 160h |  | 6,000 |  |
| 11 | Customer Test |  | 1w | 2003-10-13 | 2003-10-17 | 6, 10, 9 |  | 2003-10-06 | 2003-10-10 | 1w | 0d | Technician | 40h |  | 6,000 |  |
| 12 | Project Complete | milestone | 0d | 2003-10-17 | 2003-10-17 | 11 |  | 2003-10-10 | 2003-10-10 | 0d | 0d |  |  |  |  |  |
